# Projekt_jo_02_03

How a schedule from MS Project changed from version to version. A marks actual dates.

## Version 1 (data date 2008-08-29, saved 2008-06-11, file Projekt_05_alap_2007nyers.mpp)

| ID | WBS | Task | Duration | Start | Finish | Predecessors | Total float |
| --- | --- | --- | --- | --- | --- | --- | --- |
| 1 |  | Célmeghatározás | 6.5d | 2008-10-27 | 2008-11-04 |  | 0d |
| 2 |  | Hálózatfejlesztés | 11d | 2008-11-04 | 2008-11-19 | 1 | 0d |
| 3 | 3 | **Betanítás** | 13d | 2008-11-12 | 2008-12-01 |  | 5d |
| 4 | 3.1 | **oktatók felkészítése** | 4d | 2008-11-12 | 2008-11-18 |  | 16d |
| 5 |  | oktatók betanítása | 4d | 2008-11-12 | 2008-11-18 | 2SS+6d | 16d |
| 6 | 3.2 | **Minőségbiztosítás részleg betanítása** | 8d | 2008-11-19 | 2008-12-01 |  | 0d |
| 7 |  | csoport 1. | 2d | 2008-11-19 | 2008-11-21 | 2 | 0d |
| 8 |  | csoport 2. | 3d | 2008-11-21 | 2008-11-26 | 7 | 7d |
| 9 |  | csoport 3. | 3d | 2008-11-26 | 2008-12-01 | 8 | 7d |
| 10 |  | csoport 1. | 3d | 2008-11-21 | 2008-11-26 | 7 | 0d |
| 11 |  | csoport 2. | 3d | 2008-11-26 | 2008-12-01 | 10 | 7d |
| 12 | 3.3 | **Karbantartási részleg betanítása** | 2d | 2008-11-19 | 2008-11-21 |  | 7d |
| 13 |  | csoport 1. | 2d | 2008-11-19 | 2008-11-21 | 7SS | 7d |
| 14 |  | csoport 1. | 2d | 2008-11-19 | 2008-11-21 | 7SS | 7d |
| 15 | 4 | **Adatfeltöltés** | 15d | 2008-11-19 | 2008-12-10 |  | 0d |
| 16 | 4.1 | **Minőségbiztosítási részleg adatfeltöltés** | 15d | 2008-11-19 | 2008-12-10 |  | 0d |
| 17 |  | adatfeltöltés | 12d | 2008-11-19 | 2008-12-05 | 7SS, 9FF-3d | 3d |
| 18 |  | adatfeltöltés | 10d | 2008-11-26 | 2008-12-10 | 10, 11FF-2d | 0d |
| 19 | 4.2 | **Karbantartási részleg adatfeltöltés** | 13d | 2008-11-21 | 2008-12-10 |  | 0d |
| 20 |  | adatfeltöltés | 6d | 2008-11-21 | 2008-12-01 | 13 | 7d |
| 21 |  | adatfeltöltés | 6d | 2008-11-21 | 2008-12-01 | 14 | 7d |
| 22 |  | adatfeltöltés kész | 0d | 2008-12-10 | 2008-12-10 | 17, 18, 20, 21 | 0d |

## Version 2 (data date 2008-11-24, saved 2012-02-06, file Projekt_05_alap_2007.mpp)

Last finish 2008-12-10 → 2008-12-17 (+7d). Complete tasks 0 → 4.

Added:

| ID | Task | Duration | Start | Finish | Predecessors | Constraint | Resources |
| --- | --- | --- | --- | --- | --- | --- | --- |
| 6 | program tesztelése | 6d | 2008-11-09 A | 2008-11-15 A | 5SS+1d |  | László Róbert; Á oktató 1 [50%]; Á oktató 2 [50%]; Á oktató 3 [50%] |
| 7 | látszat | 1d | 2008-11-25 | 2008-11-25 | 6 | start no earlier than 2008-11-24 |  |
| 8 | jegyzet készítése | 8d | 2008-11-25 | 2008-12-02 | 6SS+2d, 7FF, 5 | start no earlier than 2008-11-24 | Á oktató 1 [50%]; Á oktató 2 [50%]; Á oktató 3 [50%] |
| 9 | oktatók felkészítése kész | 0d | 2008-12-02 | 2008-12-02 | 8 | start no earlier than 2008-11-24 |  |

Changed:

| ID | Task | Start | Finish | Duration | Complete | Total float | Predecessors | Other |
| --- | --- | --- | --- | --- | --- | --- | --- | --- |
| 1 | Célmeghatározás | 2008-10-27 A | 2008-11-04 → 2008-11-02 A (-2d) |  | 0% → 100% | 0d → none |  | baseline start none → 2008-10-27; baseline finish none → 2008-11-02 |
| 2 | Hálózatfejlesztés | 2008-11-04 → 2008-11-02 A (-2d) | 2008-11-19 → 2008-11-11 A (-8d) | 11d → 9d | 0% → 100% | 0d → none |  | baseline start none → 2008-11-02; baseline finish none → 2008-11-13 |
| 3 | **Betanítás** | 2008-11-12 → 2008-11-08 A (-4d) | 2008-12-01 → 2008-12-10 (+9d) | 13d → 32.5d | 0% → 27% | 5d → 7d |  | baseline start none → 2008-11-08; baseline finish none → 2008-11-28 |
| 4 | **oktatók felkészítése** | 2008-11-12 → 2008-11-08 A (-4d) | 2008-11-18 → 2008-12-02 (+14d) | 4d → 24.5d | 0% → 53% | 16d → 0d |  | baseline start none → 2008-11-08; baseline finish none → 2008-11-20 |
| 5 | oktatók betanítása | 2008-11-12 → 2008-11-08 A (-4d) | 2008-11-18 → 2008-11-12 A (-6d) |  | 0% → 100% | 16d → none |  | baseline start none → 2008-11-08; baseline finish none → 2008-11-12 |
| 10 | **Minőségbiztosítás részleg betanítása** | 2008-11-19 → 2008-12-03 (+14d) | 2008-12-01 → 2008-12-10 (+9d) |  |  |  |  | baseline start none → 2008-11-20; baseline finish none → 2008-11-28 |
| 11 | csoport 1. | 2008-11-19 → 2008-12-03 (+14d) | 2008-11-21 → 2008-12-04 (+13d) |  |  |  | 2 → 2, 9 | constraint none → start no earlier than 2008-11-24; baseline start none → 2008-11-20; baseline finish none → 2008-11-22 |
| 12 | csoport 2. | 2008-11-21 → 2008-12-05 (+14d) | 2008-11-26 → 2008-12-07 (+11d) |  |  |  |  | constraint none → start no earlier than 2008-11-24; baseline start none → 2008-11-22; baseline finish none → 2008-11-25 |
| 13 | csoport 3. | 2008-11-26 → 2008-12-08 (+12d) | 2008-12-01 → 2008-12-10 (+9d) |  |  |  |  | baseline start none → 2008-11-25; baseline finish none → 2008-11-28 |
| 14 | csoport 1. | 2008-11-21 → 2008-12-05 (+14d) | 2008-11-26 → 2008-12-07 (+11d) |  |  |  |  | constraint none → start no earlier than 2008-11-24; baseline start none → 2008-11-22; baseline finish none → 2008-11-25 |
| 15 | csoport 2. | 2008-11-26 → 2008-12-08 (+12d) | 2008-12-01 → 2008-12-10 (+9d) |  |  |  |  | baseline start none → 2008-11-25; baseline finish none → 2008-11-28 |
| 16 | **Karbantartási részleg betanítása** | 2008-11-19 → 2008-12-03 (+14d) | 2008-11-21 → 2008-12-04 (+13d) |  |  |  |  | baseline start none → 2008-11-20; baseline finish none → 2008-11-22 |
| 17 | csoport 1. | 2008-11-19 → 2008-12-03 (+14d) | 2008-11-21 → 2008-12-04 (+13d) |  |  |  |  | constraint none → start no earlier than 2008-11-24; baseline start none → 2008-11-20; baseline finish none → 2008-11-22 |
| 18 | csoport 1. | 2008-11-19 → 2008-12-03 (+14d) | 2008-11-21 → 2008-12-04 (+13d) |  |  |  |  | constraint none → start no earlier than 2008-11-24; baseline start none → 2008-11-20; baseline finish none → 2008-11-22 |
| 19 | **Adatfeltöltés** | 2008-11-19 → 2008-12-03 (+14d) | 2008-12-10 → 2008-12-17 (+7d) |  |  |  |  | baseline start none → 2008-11-20; baseline finish none → 2008-12-05 |
| 20 | **Minőségbiztosítási részleg adatfeltöltés** | 2008-11-19 → 2008-12-03 (+14d) | 2008-12-10 → 2008-12-17 (+7d) |  |  |  |  | baseline start none → 2008-11-20; baseline finish none → 2008-12-05 |
| 21 | adatfeltöltés | 2008-11-19 → 2008-12-03 (+14d) | 2008-12-05 → 2008-12-14 (+9d) |  |  |  |  | constraint none → start no earlier than 2008-11-24; baseline start none → 2008-11-20; baseline finish none → 2008-12-02 |
| 22 | adatfeltöltés | 2008-11-26 → 2008-12-08 (+12d) | 2008-12-10 → 2008-12-17 (+7d) |  |  |  |  | resources Á műszaki informatikus 2; Á műszaki informatikus 3 → Á műszaki informatikus 4; Á műszaki informatikus 3; baseline start none → 2008-11-25; baseline finish none → 2008-12-05 |
| 23 | **Karbantartási részleg adatfeltöltés** | 2008-11-21 → 2008-12-05 (+14d) | 2008-12-10 → 2008-12-17 (+7d) |  |  |  |  | baseline start none → 2008-11-22; baseline finish none → 2008-12-05 |
| 24 | adatfeltöltés | 2008-11-21 → 2008-12-05 (+14d) | 2008-12-01 → 2008-12-10 (+9d) |  |  |  |  | constraint none → start no earlier than 2008-11-24; baseline start none → 2008-11-22; baseline finish none → 2008-11-28 |
| 25 | adatfeltöltés | 2008-11-21 → 2008-12-05 (+14d) | 2008-12-01 → 2008-12-10 (+9d) |  |  |  |  | constraint none → start no earlier than 2008-11-24; baseline start none → 2008-11-22; baseline finish none → 2008-11-28 |
| 26 | adatfeltöltés kész | 2008-12-10 → 2008-12-17 (+7d) | 2008-12-10 → 2008-12-17 (+7d) |  |  |  |  | baseline start none → 2008-12-05; baseline finish none → 2008-12-05 |
